# Project Plan

Schedule from MS Project, 2012-10-01 to 2013-04-12, A marks actual dates.

## Calendars

- Standard: Mon-Fri 08:00-12:00, 13:00-17:00; Sat-Sun off. Exceptions (off unless hours are given): 2012-10-13 to 2012-10-14 08:00-12:00, 13:00-17:00, 2012-10-20 08:00-12:00, 13:00-17:00, 2012-10-27 to 2012-10-28 08:00-12:00, 13:00-17:00, 2012-11-03 08:00-12:00, 13:00-17:00.

## Resources

| Resource |
| --- |
| Samanta Zdravkovska |
| Martin Ilioski |
| Darko Aleksovski |
| Filip Petrovski |
| Goran Hristovski |
| Sashe Spasov |
| Ana Grozdanovska |

## Schedule

| ID | WBS | Task | Duration | Start | Finish | Predecessors | Complete | Remaining | Total slack | Free slack | Constraint | Resources | Work | Actual work |
| --- | --- | --- | --- | --- | --- | --- | --- | --- | --- | --- | --- | --- | --- | --- |
| 1 | 1 | **Inception** | 25d? | 2012-10-01 A | 2012-10-28 A |  | 100% |  |  |  |  |  | 576h | 576h |
| 2 | 1.1 | **Project management** | 10d? | 2012-10-01 A | 2012-10-12 A |  | 100% |  |  |  |  |  | 232h | 232h |
| 3 | 1.1.1 | Conceive new project | 2d? | 2012-10-01 A | 2012-10-02 A |  | 100% |  |  |  | finish no earlier than 2012-10-02 | Ana Grozdanovska; Darko Aleksovski; Filip Petrovski; Goran Hristovski; Martin Ilioski; Samanta Zdravkovska; Sashe Spasov | 112h | 112h |
| 4 | 1.1.2 | Evaluate project scope and risks | 3d | 2012-10-03 A | 2012-10-05 A | 3 | 100% |  |  |  | finish no earlier than 2012-10-05 | Ana Grozdanovska; Goran Hristovski; Martin Ilioski | 72h | 72h |
| 5 | 1.1.3 | Develop project plan | 3d | 2012-10-08 A | 2012-10-10 A | 4 | 100% |  |  |  | finish no earlier than 2012-10-10 | Samanta Zdravkovska | 24h | 24h |
| 6 | 1.1.4 | Plan remainder of initial iteration | 1d? | 2012-10-12 A | 2012-10-12 A | 5 | 100% |  |  |  | start no earlier than 2012-10-12 | Darko Aleksovski; Filip Petrovski; Sashe Spasov | 24h | 24h |
| 7 | 1.2 | **Business modeling** | 15d? | 2012-10-10 A | 2012-10-25 A |  | 100% |  |  |  |  |  | 248h | 248h |
| 8 | 1.2.1 | Find business actors and use cases | 2d? | 2012-10-10 A | 2012-10-11 A | 4 | 100% |  |  |  | finish no earlier than 2012-10-11 | Darko Aleksovski; Filip Petrovski | 32h | 32h |
| 9 | 1.2.2 | Identify business processes | 3d? | 2012-10-15 A | 2012-10-17 A |  | 100% |  |  |  | finish no earlier than 2012-10-17 | Ana Grozdanovska; Martin Ilioski | 48h | 48h |
| 10 | 1.2.3 | Define roles and responsabilities | 1d? | 2012-10-13 A | 2012-10-13 A | 5 | 100% |  |  |  | finish no earlier than 2012-10-13 | Samanta Zdravkovska | 8h | 8h |
| 11 | 1.2.4 | Describe the main use cases | 3d? | 2012-10-14 A | 2012-10-16 A | 8 | 100% |  |  |  | finish no earlier than 2012-10-16 | Darko Aleksovski; Samanta Zdravkovska; Filip Petrovski; Sashe Spasov | 96h | 96h |
| 12 | 1.2.5 | Structure the business use case model | 1d? | 2012-10-19 A | 2012-10-19 A | 11 | 100% |  |  |  | finish no earlier than 2012-10-19 | Ana Grozdanovska; Goran Hristovski; Martin Ilioski | 24h | 24h |
| 13 | 1.2.6 | Review business use case model | 1d? | 2012-10-25 A | 2012-10-25 A | 12 | 100% |  |  |  | finish no earlier than 2012-10-25 | Ana Grozdanovska; Filip Petrovski; Goran Hristovski; Samanta Zdravkovska; Sashe Spasov | 40h | 40h |
| 14 | 1.3 | **Requirements** | 5d? | 2012-10-22 A | 2012-10-26 A |  | 100% |  |  |  |  |  | 32h | 32h |
| 15 | 1.3.1 | Prioritize use cases | 1d? | 2012-10-22 A | 2012-10-22 A | 11, 12 | 100% |  |  |  | finish no earlier than 2012-10-22 | Darko Aleksovski; Martin Ilioski | 16h | 16h |
| 16 | 1.3.2 | Define system and constraints | 1d? | 2012-10-26 A | 2012-10-26 A |  | 100% |  |  |  | start no earlier than 2012-10-26 | Filip Petrovski; Sashe Spasov | 16h | 16h |
| 17 | 1.4 | **Analysis and design** | 1d? | 2012-10-27 A | 2012-10-27 A |  | 100% |  |  |  |  |  | 32h | 32h |
| 18 | 1.4.1 | Perform architectural synthesis | 1d? | 2012-10-27 A | 2012-10-27 A | 7, 14 | 100% |  |  |  | finish no earlier than 2012-10-26 | Ana Grozdanovska; Darko Aleksovski; Samanta Zdravkovska; Sashe Spasov | 32h | 32h |
| 19 | 1.5 | **Environment** | 2d? | 2012-10-20 A | 2012-10-22 A |  | 100% |  |  |  |  |  | 16h | 16h |
| 20 | 1.5.1 | Prepare guidelines for iteration | 2d? | 2012-10-20 A | 2012-10-22 A | 6 | 100% |  |  |  | start no earlier than 2012-10-20 | Samanta Zdravkovska | 16h | 16h |
| 21 | 1.6 | **Configuration and Change management** | 17d? | 2012-10-11 A | 2012-10-28 A |  | 100% |  |  |  |  |  | 16h | 16h |
| 22 | 1.6.1 | Plan project configuration and change control | 1d? | 2012-10-11 A | 2012-10-11 A | 5 | 100% |  |  |  | finish no earlier than 2012-10-10 | Samanta Zdravkovska | 8h | 8h |
| 23 | 1.6.2 | Manage change requests | 1d? | 2012-10-28 A | 2012-10-28 A | 22 | 100% |  |  |  | finish no earlier than 2012-10-28 | Samanta Zdravkovska | 8h | 8h |
| 24 | 2 | **Elaboration** | 97d? | 2012-10-29 A | 2013-03-11 | 1 | 56% | 42.98d? | 0d |  |  |  | 792h | 560h |
| 25 | 2.1 | **Iteration 1** | 71.5d? | 2012-10-29 A | 2013-02-04 | 1 | 66% | 24.32d? | 10.7d | 0d |  |  | 792h | 560h |
| 26 | 2.1.1 | **Business modeling** | 3d? | 2012-10-29 A | 2012-10-31 A | 7 | 100% |  |  |  |  |  | 104h | 104h |
| 27 | 2.1.1.1 | Find and describe business entities | 3d? | 2012-10-29 A | 2012-10-31 A |  | 100% |  |  |  | finish no earlier than 2012-10-31 | Ana Grozdanovska; Goran Hristovski; Martin Ilioski | 72h | 72h |
| 28 | 2.1.1.2 | Review the Business Object Model | 1d? | 2012-10-31 A | 2012-10-31 A |  | 100% |  |  |  | finish no earlier than 2012-10-31 | Darko Aleksovski; Filip Petrovski; Samanta Zdravkovska; Sashe Spasov | 32h | 32h |

| ID | WBS | Task | Duration | Start | Finish | Predecessors | Complete | Remaining | Total slack | Free slack | Constraint | Resources | Work | Actual work |
| --- | --- | --- | --- | --- | --- | --- | --- | --- | --- | --- | --- | --- | --- | --- |
| 29 | 2.1.2 | **Requirements** | 2d? | 2012-10-29 A | 2012-10-30 A | 14 | 100% |  |  |  |  |  | 16h | 16h |
| 30 | 2.1.2.1 | Manage dependencies | 2d? | 2012-10-29 A | 2012-10-30 A |  | 100% |  |  |  | finish no earlier than 2012-10-30 | Samanta Zdravkovska | 16h | 16h |
| 31 | 2.1.3 | **Detail prioritized use cases** | 8d? | 2012-11-01 A | 2012-11-09 A | 15 | 100% |  |  |  |  |  | 192h | 192h |
| 32 | 2.1.3.1 | Structure the use case model | 1d? | 2012-11-08 A | 2012-11-08 A | 33 | 100% |  |  |  | finish no earlier than 2012-11-05 | Filip Petrovski; Sashe Spasov | 16h | 16h |
| 33 | 2.1.3.2 | Detail use cases | 4d? | 2012-11-03 A | 2012-11-07 A |  | 100% |  |  |  | start no earlier than 2012-11-03 | Darko Aleksovski; Samanta Zdravkovska | 64h | 64h |
| 34 | 2.1.3.3 | User-Interface Modeling | 2d? | 2012-11-01 A | 2012-11-02 A |  | 100% |  |  |  | start no earlier than 2012-11-01 | Ana Grozdanovska; Martin Ilioski | 32h | 32h |
| 35 | 2.1.3.4 | User-Interface Prototyping | 3d? | 2012-11-05 A | 2012-11-07 A | 34 | 100% |  |  |  | finish no earlier than 2012-11-07 | Filip Petrovski; Goran Hristovski | 48h | 48h |
| 36 | 2.1.3.5 | Review Requirements | 1d? | 2012-11-09 A | 2012-11-09 A |  | 100% |  |  |  | start no earlier than 2012-11-09 | Ana Grozdanovska; Darko Aleksovski; Samanta Zdravkovska; Sashe Spasov | 32h | 32h |
| 37 | 2.1.4 | **Analysis and design** | 1d? | 2012-11-12 A | 2012-11-12 A | 17 | 100% |  |  |  |  |  | 8h | 8h |
| 38 | 2.1.4.1 | Architectural Analysis | 1d? | 2012-11-12 A | 2012-11-12 A |  | 100% |  |  |  | finish no earlier than 2012-11-12 | Filip Petrovski | 8h | 8h |
| 39 | 2.1.5 | **Prioritized Use-Case Analysis** | 5d? | 2012-11-12 A | 2012-11-16 A | 31 | 100% |  |  |  |  |  | 80h | 80h |
| 40 | 2.1.5.1 | Analyse use cases | 1d? | 2012-11-12 A | 2012-11-12 A |  | 100% |  |  |  | finish no earlier than 2012-11-12 | Darko Aleksovski; Sashe Spasov | 16h | 16h |
| 41 | 2.1.5.2 | Architectural Design | 3d? | 2012-11-13 A | 2012-11-15 A |  | 100% |  |  |  | finish no earlier than 2012-11-15 | Ana Grozdanovska; Samanta Zdravkovska | 48h | 48h |
| 42 | 2.1.5.3 | Review the Architecture | 1d? | 2012-11-16 A | 2012-11-16 A |  | 100% |  |  |  | finish no earlier than 2012-11-16 | Goran Hristovski; Martin Ilioski | 16h | 16h |
| 43 | 2.1.6 | **Prioritized Use-Case Design** | 29.5d? | 2012-11-19 A | 2012-12-28 | 39 | 50% | 14.75d? | 5.5d | 0d |  |  | 208h | 104h |
| 44 | 2.1.6.1 | Design use cases | 3d? | 2012-11-19 A | 2012-12-11 |  | 50% | 1.5d? | 18.5d |  | finish no earlier than 2012-11-21 | Darko Aleksovski; Filip Petrovski; Samanta Zdravkovska; Sashe Spasov | 96h | 48h |
| 45 | 2.1.6.2 | Database Design | 3d? | 2012-11-21 A | 2012-12-18 |  | 50% | 1.5d? | 13.5d |  | start no earlier than 2012-11-21 | Ana Grozdanovska; Goran Hristovski; Martin Ilioski | 72h | 36h |
| 46 | 2.1.6.3 | Prioritized Class Design | 2d? | 2012-11-22 A | 2012-12-24 |  | 50% | 1d? | 9d |  | start no earlier than 2012-11-22 | Samanta Zdravkovska; Sashe Spasov | 32h | 16h |
| 47 | 2.1.6.4 | Review the Design | 1d? | 2012-11-23 A | 2012-12-28 |  | 50% | 0.5d? | 5.5d |  | start no earlier than 2012-11-23 | Darko Aleksovski | 8h | 4h |
| 48 | 2.1.7 | **Implementation** | 41d? | 2012-11-26 A | 2013-01-21 | 43 | 24% | 31.1d? | 0d |  |  |  | 160h | 44h |
| 49 | 2.1.7.1 | Structure the Implementation Model | 2d? | 2012-11-26 A | 2013-01-14 |  | 50% | 1d? | 12d |  | finish no earlier than 2012-11-27 | Sashe Spasov | 16h | 8h |
| 50 | 2.1.7.2 | Implement Prioritized Components | 9d? | 2012-11-27 A | 2013-01-16 |  | 11% | 8d? | 10d |  | finish no earlier than 2012-11-28 | Darko Aleksovski; Filip Petrovski | 104h | 16h |
| 51 | 2.1.7.3 | Fix Defects | 2d? | 2012-11-28 A | 2013-01-21 |  | 50% | 1d? | 0d |  | finish no earlier than 2012-11-29 | Samanta Zdravkovska | 16h | 8h |
| 52 | 2.1.7.4 | Integrate System | 1.5d? | 2012-11-30 A | 2013-01-21 |  | 33% | 1d? | 0.5d |  | finish no earlier than 2012-11-30 | Ana Grozdanovska; Martin Ilioski; Goran Hristovski | 24h | 12h |

| ID | WBS | Task | Duration | Start | Finish | Predecessors | Complete | Remaining | Total slack | Free slack | Constraint | Resources | Work | Actual work |
| --- | --- | --- | --- | --- | --- | --- | --- | --- | --- | --- | --- | --- | --- | --- |
| 53 | 2.1.8 | **Management** | 45.5d? | 2012-12-03 A | 2013-02-04 | 48 | 50% | 22.75d? | 10.7d |  |  |  | 24h | 12h |
| 54 | 2.1.8.1 | Evaluate the Iteration | 1d? | 2012-12-03 A | 2013-01-28 |  | 50% | 0.5d? | 15.7d |  |  | Darko Aleksovski; Martin Ilioski | 16h | 8h |
| 55 | 2.1.8.2 | Update Project Plan | 1d? | 2012-12-03 A | 2013-02-04 |  | 50% | 0.5d? | 10.7d |  |  | Samanta Zdravkovska | 8h | 4h |
| 56 | 2.2 | **Iteration 2** | 27.5d? | 2013-01-31 A | 2013-03-11 | 25 | 46% | 14.8d? | 0d |  |  |  |  |  |
| 57 | 2.2.1 | **Requirements** | 26d? | 2013-01-31 A | 2013-03-08 |  | 50% | 13d? | 1.5d |  |  |  |  |  |
| 58 | 2.2.1.1 | Manage dependencies | 1d? | 2013-01-31 A | 2013-03-08 |  | 50% | 0.5d? | 1.5d |  | finish no earlier than 2012-12-04 |  |  |  |
| 59 | 2.2.2 | **Detail prioritized use cases** | 10.5d? | 2013-01-31 A | 2013-02-14 |  | 46% | 5.64d? | 0.5d | 0d |  |  |  |  |
| 60 | 2.2.2.1 | Detail use cases | 3.5d? | 2013-01-31 A | 2013-02-12 |  | 57% | 1.5d? | 3d |  | finish no earlier than 2012-12-07 |  |  |  |
| 61 | 2.2.2.2 | Structure the use case model | 5d? | 2013-01-31 A | 2013-02-14 |  | 40% | 3d? | 0.5d |  | finish no earlier than 2012-12-07 |  |  |  |
| 62 | 2.2.2.3 | User-Interface Modeling | 1.5d? | 2013-01-31 A | 2013-02-08 |  | 50% | 0.75d? | 4.75d |  | finish no earlier than 2012-12-06 |  |  |  |
| 63 | 2.2.2.4 | User-Interface Prototyping | 2d? | 2013-01-31 A | 2013-02-11 |  | 50% | 1d? | 3.5d |  | finish no earlier than 2012-12-07 |  |  |  |
| 64 | 2.2.2.5 | Review Requirements | 1.5d? | 2013-01-31 A | 2013-02-13 |  | 33% | 1d? | 1.5d |  | finish no earlier than 2012-12-07 |  |  |  |
| 65 | 2.2.3 | **Analysis and design** | 27.5d? | 2013-01-31 A | 2013-03-11 | 37 | 50% | 13.75d? | 0d |  |  |  |  |  |
| 66 | 2.2.3.1 | Architectural Analysis | 2d? | 2013-01-31 A | 2013-03-11 |  | 50% | 1d? | 0d |  | finish no earlier than 2012-12-11 |  |  |  |
| 67 | 2.2.4 | **Prioritized Use-Case Analysis** | 10d? | 2013-02-06 A | 2013-02-20 | 59 | 50% | 5d? | 2d | 0d |  |  |  |  |
| 68 | 2.2.4.1 | Analyse use cases | 3d? | 2013-02-06 A | 2013-02-19 |  | 50% | 1.5d? | 3d |  | finish no earlier than 2012-12-12 |  |  |  |
| 69 | 2.2.4.2 | Architectural Design | 3d? | 2013-02-06 A | 2013-02-20 |  | 50% | 1.5d? | 2d |  | finish no earlier than 2012-12-14 |  |  |  |
| 70 | 2.2.4.3 | Review the Architecture | 1d? | 2013-02-06 A | 2013-02-20 |  | 50% | 0.5d? | 2d |  | finish no earlier than 2012-12-14 |  |  |  |
| 71 | 2.2.5 | **Prioritized Use-Case Design** | 14d? | 2013-02-11 A | 2013-03-01 | 67 | 50% | 7d? | 2d | 0d |  |  |  |  |
| 72 | 2.2.5.1 | Design use cases | 5d? | 2013-02-11 A | 2013-02-27 |  | 50% | 2.5d? | 4d |  | finish no earlier than 2012-12-21 |  |  |  |
| 73 | 2.2.5.2 | Database Design | 5d? | 2013-02-11 A | 2013-02-28 |  | 50% | 2.5d? | 1d |  | finish no earlier than 2012-12-21 |  |  |  |
| 74 | 2.2.5.3 | Prioritized Class Design | 5d? | 2013-02-11 A | 2013-03-01 |  | 50% | 2.5d? | 2d |  | finish no earlier than 2012-12-21 |  |  |  |
| 75 | 2.2.5.4 | Review the Design | 1d? | 2013-02-11 A | 2013-02-25 |  | 50% | 0.5d? | 4d |  | start no earlier than 2012-12-21 |  |  |  |
| 76 | 2.2.6 | **Implementation** | 14.5d? | 2013-02-18 A | 2013-03-08 | 71 | 40% | 8.7d? | 1d |  |  |  |  |  |
| 77 | 2.2.6.1 | Structure the Implementation Model | 3d? | 2013-02-18 A | 2013-03-05 |  | 33% | 2d? | 4.5d |  | finish no earlier than 2012-12-25 |  |  |  |
| 78 | 2.2.6.2 | Implement Prioritized Components | 3d? | 2013-02-18 A | 2013-03-07 |  | 50% | 1.5d? | 2.5d |  | finish no earlier than 2012-12-27 |  |  |  |
| 79 | 2.2.6.3 | Fix Defects | 3d? | 2013-02-18 A | 2013-03-08 |  | 33% | 2d? | 1d |  | finish no earlier than 2012-12-28 |  |  |  |
| 80 | 2.2.6.4 | Integrate System | 1d? | 2013-02-18 A | 2013-03-01 |  | 50% | 0.5d? | 6d |  | finish no earlier than 2012-12-31 |  |  |  |

| ID | WBS | Task | Duration | Start | Finish | Predecessors | Complete | Remaining | Total slack | Constraint |
| --- | --- | --- | --- | --- | --- | --- | --- | --- | --- | --- |
| 81 | 2.2.7 | **Management** | 26d? | 2013-01-31 A | 2013-03-08 |  | 33% | 17.33d? | 1.5d |  |
| 82 | 2.2.7.1 | Evaluate the Iteration | 1d? | 2013-01-31 A | 2013-03-04 |  | 50% | 0.5d? | 5.5d | start no earlier than 2013-01-02 |
| 83 | 2.2.7.2 | Update Project Plan | 2d? | 2013-01-31 A | 2013-03-08 |  | 25% | 1.5d? | 1.5d | start no earlier than 2013-01-03 |
| 84 | 3 | **Construction** | 22d? | 2013-03-12 | 2013-04-10 | 25, 56 |  |  | 0d |  |
| 85 | 3.1 | **Iteration 3** | 10d? | 2013-03-12 | 2013-03-25 | 25, 56 |  |  | 0d |  |
| 86 | 3.1.1 | **Requirements** | 1d? | 2013-03-12 | 2013-03-12 |  |  |  | 9d |  |
| 87 | 3.1.1.1 | Manage dependencies | 1d? | 2013-03-12 | 2013-03-12 |  |  |  | 9d | finish no earlier than 2013-01-14 |
| 88 | 3.1.2 | **Detail prioritized use cases** | 3d? | 2013-03-12 | 2013-03-14 |  |  |  | 7d |  |
| 89 | 3.1.2.1 | Detail use cases | 3d? | 2013-03-12 | 2013-03-14 |  |  |  | 7d | finish no earlier than 2013-01-17 |
| 90 | 3.1.2.2 | Structure the use case model | 2d? | 2013-03-12 | 2013-03-13 |  |  |  | 8d | finish no earlier than 2013-01-18 |
| 91 | 3.1.2.3 | User-Interface Modeling | 3d? | 2013-03-12 | 2013-03-14 |  |  |  | 7d | finish no earlier than 2013-01-17 |
| 92 | 3.1.2.4 | User-Interface Prototyping | 2d? | 2013-03-12 | 2013-03-13 |  |  |  | 8d | finish no earlier than 2013-01-18 |
| 93 | 3.1.2.5 | Review Requirements | 1d? | 2013-03-12 | 2013-03-12 |  |  |  | 9d | finish no earlier than 2013-01-18 |
| 94 | 3.1.3 | **Analysis and design** | 1d? | 2013-03-12 | 2013-03-12 |  |  |  | 9d |  |
| 95 | 3.1.3.1 | Architectural Analysis | 1d? | 2013-03-12 | 2013-03-12 |  |  |  | 9d | finish no earlier than 2013-01-21 |
| 96 | 3.1.4 | **Prioritized Use-Case Analysis** | 2d? | 2013-03-12 | 2013-03-13 |  |  |  | 0d |  |
| 97 | 3.1.4.1 | Analyse use cases | 2d? | 2013-03-12 | 2013-03-13 |  |  |  | 0d | finish no earlier than 2013-01-23 |
| 98 | 3.1.4.2 | Architectural Design | 2d? | 2013-03-12 | 2013-03-13 |  |  |  | 0d | finish no earlier than 2013-01-24 |
| 99 | 3.1.4.3 | Review the Architecture | 1d? | 2013-03-12 | 2013-03-12 |  |  |  | 1d | finish no earlier than 2013-01-25 |
| 100 | 3.1.5 | **Prioritized Use-Case Design** | 5d? | 2013-03-14 | 2013-03-20 | 96 |  |  | 0d |  |
| 101 | 3.1.5.1 | Design use cases | 5d? | 2013-03-14 | 2013-03-20 |  |  |  | 0d | finish no earlier than 2013-02-01 |
| 102 | 3.1.5.2 | Database Design | 4d? | 2013-03-14 | 2013-03-19 |  |  |  | 1d | finish no earlier than 2013-01-31 |
| 103 | 3.1.5.3 | Prioritized Class Design | 4d? | 2013-03-14 | 2013-03-19 |  |  |  | 1d | finish no earlier than 2013-01-31 |
| 104 | 3.1.5.4 | Review the Design | 1d? | 2013-03-14 | 2013-03-14 |  |  |  | 4d | start no earlier than 2013-02-01 |

| ID | WBS | Task | Duration | Start | Finish | Predecessors | Total slack | Constraint |
| --- | --- | --- | --- | --- | --- | --- | --- | --- |
| 105 | 3.1.6 | **Implementation** | 1d? | 2013-03-21 | 2013-03-21 | 100 | 0d |  |
| 106 | 3.1.6.1 | Structure the Implementation Model | 1d? | 2013-03-21 | 2013-03-21 |  | 0d | finish no earlier than 2013-02-04 |
| 107 | 3.1.6.2 | Implement Prioritized Components | 1d? | 2013-03-21 | 2013-03-21 |  | 0d | finish no earlier than 2013-02-05 |
| 108 | 3.1.6.3 | Fix Defects | 1d? | 2013-03-21 | 2013-03-21 |  | 0d | finish no earlier than 2013-02-06 |
| 109 | 3.1.6.4 | Integrate System | 1d? | 2013-03-21 | 2013-03-21 |  | 0d | finish no earlier than 2013-02-07 |
| 110 | 3.1.7 | **Test** | 2d? | 2013-03-22 | 2013-03-25 | 105 | 0d |  |
| 111 | 3.1.7.1 | Design Test (Integration & System) | 2d? | 2013-03-22 | 2013-03-25 |  | 0d | finish no earlier than 2013-02-12 |
| 112 | 3.1.7.2 | Implement Test | 1d? | 2013-03-22 | 2013-03-22 |  | 1d | finish no earlier than 2013-02-13 |
| 113 | 3.1.7.3 | Execute Integration Test | 1d? | 2013-03-22 | 2013-03-22 |  | 1d | start no earlier than 2013-02-14 |
| 114 | 3.1.7.4 | Execute System Test | 1d? | 2013-03-22 | 2013-03-22 |  | 1d | start no earlier than 2013-02-14 |
| 115 | 3.1.7.5 | Execute Performance Tests | 1d? | 2013-03-22 | 2013-03-22 |  | 1d | start no earlier than 2013-02-14 |
| 116 | 3.1.7.6 | Evaluate Test | 1d? | 2013-03-22 | 2013-03-22 |  | 1d | start no earlier than 2013-02-15 |
| 117 | 3.1.8 | **Management** | 1d? | 2013-03-12 | 2013-03-12 |  | 9d |  |
| 118 | 3.1.8.1 | Refine Iteration Plan | 1d? | 2013-03-12 | 2013-03-12 |  | 9d | start no earlier than 2013-02-18 |
| 119 | 3.1.8.2 | Evaluate the Iteration | 1d? | 2013-03-12 | 2013-03-12 |  | 9d | start no earlier than 2013-02-18 |
| 120 | 3.1.8.3 | Update Project Plan | 1d? | 2013-03-12 | 2013-03-12 |  | 9d | start no earlier than 2013-02-18 |
| 121 | 3.2 | **Iteration 4** | 12d? | 2013-03-26 | 2013-04-10 | 85 | 0d |  |
| 122 | 3.2.1 | **Requirements** | 1d? | 2013-03-26 | 2013-03-26 |  | 11d |  |
| 123 | 3.2.1.1 | Manage dependencies | 1d? | 2013-03-26 | 2013-03-26 |  | 11d | finish no earlier than 2013-02-11 |
| 124 | 3.2.2 | **Detail prioritized use cases** | 3d? | 2013-03-26 | 2013-03-28 |  | 0d |  |
| 125 | 3.2.2.1 | Detail use cases | 3d? | 2013-03-26 | 2013-03-28 |  | 0d | finish no earlier than 2013-02-13 |
| 126 | 3.2.2.2 | Structure the use case model | 1d? | 2013-03-26 | 2013-03-26 |  | 2d | finish no earlier than 2013-02-13 |
| 127 | 3.2.2.3 | User-Interface Modeling | 1d? | 2013-03-26 | 2013-03-26 |  | 2d | finish no earlier than 2013-02-14 |
| 128 | 3.2.2.4 | User-Interface Prototyping | 1d? | 2013-03-26 | 2013-03-26 |  | 2d | finish no earlier than 2013-02-15 |
| 129 | 3.2.2.5 | Review Requirements | 1d? | 2013-03-26 | 2013-03-26 |  | 2d | finish no earlier than 2013-02-15 |

| ID | WBS | Task | Duration | Start | Finish | Predecessors | Total slack | Constraint |
| --- | --- | --- | --- | --- | --- | --- | --- | --- |
| 130 | 3.2.3 | **Analysis and design** | 1d? | 2013-03-29 | 2013-03-29 | 124 | 8d |  |
| 131 | 3.2.3.1 | Architectural Analysis | 1d? | 2013-03-29 | 2013-03-29 |  | 8d | finish no earlier than 2013-02-18 |
| 132 | 3.2.4 | **Prioritized Use-Case Analysis** | 2d? | 2013-03-29 | 2013-04-01 | 124 | 0d |  |
| 133 | 3.2.4.1 | Analyse use cases | 2d? | 2013-03-29 | 2013-04-01 |  | 0d | finish no earlier than 2013-02-19 |
| 134 | 3.2.4.2 | Architectural Design | 2d? | 2013-03-29 | 2013-04-01 |  | 0d | finish no earlier than 2013-02-21 |
| 135 | 3.2.4.3 | Review the Architecture | 1d? | 2013-03-29 | 2013-03-29 |  | 1d | finish no earlier than 2013-02-22 |
| 136 | 3.2.5 | **Prioritized Use-Case Design** | 3d? | 2013-04-02 | 2013-04-04 | 132 | 0d |  |
| 137 | 3.2.5.1 | Design use cases | 3d? | 2013-04-02 | 2013-04-04 |  | 0d | finish no earlier than 2013-02-27 |
| 138 | 3.2.5.2 | Database Design | 3d? | 2013-04-02 | 2013-04-04 |  | 0d | finish no earlier than 2013-02-27 |
| 139 | 3.2.5.3 | Prioritized Class Design | 3d? | 2013-04-02 | 2013-04-04 |  | 0d | finish no earlier than 2013-02-27 |
| 140 | 3.2.5.4 | Review the Design | 1d? | 2013-04-02 | 2013-04-02 |  | 2d | start no earlier than 2013-02-28 |
| 141 | 3.2.6 | **Implementation** | 2d? | 2013-04-05 | 2013-04-08 | 136 | 0d |  |
| 142 | 3.2.6.1 | Structure the Implementation Model | 1d? | 2013-04-05 | 2013-04-05 |  | 1d | finish no earlier than 2013-03-01 |
| 143 | 3.2.6.2 | Implement Prioritized Components | 2d? | 2013-04-05 | 2013-04-08 |  | 0d | finish no earlier than 2013-03-05 |
| 144 | 3.2.6.3 | Fix Defects | 1d? | 2013-04-05 | 2013-04-05 |  | 1d | finish no earlier than 2013-03-05 |
| 145 | 3.2.6.4 | Integrate System | 1d? | 2013-04-05 | 2013-04-05 |  | 1d | finish no earlier than 2013-03-06 |
| 146 | 3.2.7 | **Test** | 2d? | 2013-04-09 | 2013-04-10 | 141 | 0d |  |
| 147 | 3.2.7.1 | Design Test (Integration & System) | 2d? | 2013-04-09 | 2013-04-10 |  | 0d | start no earlier than 2013-03-07 |
| 148 | 3.2.7.2 | Implement Test | 1d? | 2013-04-09 | 2013-04-09 |  | 1d | start no earlier than 2013-03-11 |
| 149 | 3.2.7.3 | Execute Integration Test | 1d? | 2013-04-09 | 2013-04-09 |  | 1d | start no earlier than 2013-03-12 |
| 150 | 3.2.7.4 | Execute System Test | 1d? | 2013-04-09 | 2013-04-09 |  | 1d | start no earlier than 2013-03-12 |
| 151 | 3.2.7.5 | Execute Performance Tests | 1d? | 2013-04-09 | 2013-04-09 |  | 1d | start no earlier than 2013-03-12 |
| 152 | 3.2.7.6 | Evaluate Test | 1d? | 2013-04-09 | 2013-04-09 |  | 1d | start no earlier than 2013-03-13 |
| 153 | 3.2.8 | **Management** | 1d? | 2013-03-26 | 2013-03-26 |  | 11d |  |
| 154 | 3.2.8.1 | Refine Iteration Plan | 1d? | 2013-03-26 | 2013-03-26 |  | 11d | start no earlier than 2013-03-14 |
| 155 | 3.2.8.2 | Evaluate the Iteration | 1d? | 2013-03-26 | 2013-03-26 |  | 11d | start no earlier than 2013-03-15 |
| 156 | 3.2.8.3 | Update Project Plan | 1d? | 2013-03-26 | 2013-03-26 |  | 11d | start no earlier than 2013-03-15 |

| ID | WBS | Task | Duration | Start | Finish | Predecessors | Total slack | Constraint |
| --- | --- | --- | --- | --- | --- | --- | --- | --- |
| 157 | 4 | **Transition** | 2d? | 2013-04-11 | 2013-04-12 | 85, 121 | 0d |  |
| 158 | 4.1 | **Iteration 5** | 2d? | 2013-04-11 | 2013-04-12 | 85, 121 | 0d |  |
| 159 | 4.1.1 | Deployment | 2d? | 2013-04-11 | 2013-04-12 |  | 0d | finish no earlier than 2013-03-12 |
| 160 | 4.1.2 | **Produce Software** | 2d? | 2013-04-11 | 2013-04-12 |  | 0d |  |
| 161 | 4.1.2.1 | Install Software | 2d? | 2013-04-11 | 2013-04-12 |  | 0d | finish no earlier than 2013-03-12 |
| 162 | 4.1.2.2 | Provide Help and Assistance to the Users | 1d? | 2013-04-11 | 2013-04-11 |  | 1d | start no earlier than 2013-03-12 |
| 163 | 4.1.2.3 | Acceptance Testing | 1d? | 2013-04-11 | 2013-04-11 |  | 1d | start no earlier than 2013-03-13 |
| 164 | 4.1.3 | **Environment** | 1d? | 2013-04-11 | 2013-04-11 |  | 1d |  |
| 165 | 4.1.3.1 | Configure Processes | 1d? | 2013-04-11 | 2013-04-11 |  | 1d | start no earlier than 2013-03-14 |
| 166 | 4.1.3.2 | Training | 1d? | 2013-04-11 | 2013-04-11 |  | 1d | start no earlier than 2013-03-15 |
